# Active Directory Deployment

Schedule from MS Project, 2001-12-14 to 2002-05-31, scheduled back from the finish, A marks actual dates.

## Calendars

- Standard: Mon-Fri 08:00-12:00, 13:00-17:00; Sat-Sun off.

## Schedule

| ID | WBS | Task | Type | Duration | Start | Finish | Predecessors | Complete | Remaining | Baseline start | Baseline finish | Baseline duration | Total slack | Free slack | Constraint |
| --- | --- | --- | --- | --- | --- | --- | --- | --- | --- | --- | --- | --- | --- | --- | --- |
| 1 | 1 | **Microsoft Windows NT Server to Windows 2000 Deployment Template** |  | 120.5d | 2001-12-14 A | 2002-05-31 |  | 30% | 84.42d | 2001-12-21 | 2002-04-30 | 92.25d | -36.75d | 0d | as late as possible |
| 2 | 1.1 | **Vision/Scope** |  | 21.75d | 2001-12-21 A | 2002-01-22 |  | 99% | 0d | 2001-12-21 | 2002-01-22 | 21.75d | 0d |  | as late as possible |
| 3 | 1.1.1 | Evaluate Active Directory features |  | 1w | 2001-12-21 A | 2001-12-28 A |  | 100% |  | 2001-12-21 | 2001-12-28 | 1w |  |  |  |
| 4 | 1.1.2 | Evaluate university's objectives |  | 1w | 2001-12-21 A | 2001-12-28 A |  | 100% |  | 2001-12-21 | 2001-12-28 | 1w |  |  |  |
| 5 | 1.1.3 | Determine technology goals and objectives |  | 1w | 2001-12-28 A | 2002-01-04 A | 3, 4 | 100% |  | 2001-12-28 | 2002-01-04 | 1w |  |  |  |
| 6 | 1.1.4 | Formulate preliminary cost/benefit analysis |  | 1w | 2002-01-03 A | 2002-01-10 A | 5FS-2.5% | 100% |  | 2002-01-03 | 2002-01-10 | 1w |  |  |  |
| 7 | 1.1.5 | Determine project scope (lab, pilot, international/regional deployment, coexistence strategies, etc) |  | 1w | 2002-01-10 A | 2002-01-17 A | 6 | 100% |  | 2002-01-10 | 2002-01-17 | 1w |  |  |  |
| 8 | 1.1.6 | Determine major milestones |  | 2d | 2002-01-17 A | 2002-01-21 A | 7 | 100% |  | 2002-01-17 | 2002-01-21 | 2d |  |  |  |
| 9 | 1.1.7 | Secure executive sponsorship/funding |  | 1d | 2002-01-21 A | 2002-01-22 A | 8 | 100% |  | 2002-01-21 | 2002-01-22 | 1d |  |  |  |
| 10 | 1.1.8 | Vision/scope complete | milestone | 0d | 2002-01-22 | 2002-01-22 | 9 |  |  | 2002-01-22 | 2002-01-22 | 0d | 93d | 0d |  |
| 11 | 1.2 | **Planning** |  | 48.75d | 2001-12-14 A | 2002-02-21 |  | 54% | 22.21d | 2001-12-21 | 2002-02-21 | 43.5d | 0d |  | as late as possible |
| 12 | 1.2.1 | **Assemble Project Teams/Define Roles** |  | 27.5d | 2001-12-14 A | 2002-01-22 |  | 75% | 6.88d | 2001-12-21 | 2002-01-22 | 22.25d | 0d |  | as late as possible |
| 13 | 1.2.1.1 | **Core Roles** |  | 0.5d | 2002-01-22 A | 2002-01-22 |  | 75% | 0.12d | 2002-01-22 | 2002-01-22 | 0.5d | 0d |  | as late as possible |
| 14 | 1.2.1.1.1 | Project manager |  | 4h | 2002-01-22 A | 2002-01-22 A | 10 | 100% |  | 2002-01-22 | 2002-01-22 | 4h |  |  |  |
| 15 | 1.2.1.1.2 | Infrastructure administrator |  | 4h | 2002-01-22 A | 2002-01-22 A | 10 | 100% |  | 2002-01-22 | 2002-01-22 | 4h |  |  |  |
| 16 | 1.2.1.1.3 | Departmental liason |  | 4h | 2002-01-22 | 2002-01-22 | 10 |  |  | 2002-01-22 | 2002-01-22 | 4h | 93d | 0d |  |
| 17 | 1.2.1.1.4 | Departmental administrators |  | 4h | 2002-01-22 A | 2002-01-22 A | 10 | 100% |  | 2002-01-22 | 2002-01-22 | 4h |  |  |  |
| 18 | 1.2.1.1.5 | Amaint administrator |  | 4h | 2002-01-22 A | 2002-01-22 A | 10 | 100% |  | 2002-01-22 | 2002-01-22 | 4h |  |  |  |
| 19 | 1.2.1.1.6 | Network administrator |  | 4h | 2002-01-22 A | 2002-01-22 A | 10 | 100% |  | 2002-01-22 | 2002-01-22 | 4h |  |  |  |
| 20 | 1.2.1.1.7 | Communication facilitator |  | 4h | 2002-01-22 A | 2002-01-22 A | 10 | 100% |  | 2002-01-22 | 2002-01-22 | 4h |  |  |  |
| 21 | 1.2.1.1.8 | Logistics management |  | 4h | 2002-01-22 | 2002-01-22 | 10 |  |  | 2002-01-22 | 2002-01-22 | 4h | 93d | 0d |  |
| 22 | 1.2.1.1.9 | Core roles complete | milestone | 0d | 2002-01-22 | 2002-01-22 | 14, 15, 16, 17, 18, 19, 20, 21 |  |  | 2002-01-22 | 2002-01-22 | 0d | 93d |  |  |
| 23 | 1.2.1.2 | Assemble project teams/roles complete | milestone | 0d | 2001-12-14 | 2001-12-14 |  |  |  | 2001-12-21 | 2001-12-21 | 0d | 110.5d | 0d |  |
| 24 | 1.2.2 | **Detail Current Computing Environment** |  | 15.25d | 2001-12-14 A | 2002-01-04 |  | 63% | 5.72d | 2001-12-21 | 2002-01-04 | 10d | 0d |  | as late as possible |
| 25 | 1.2.2.1 | Detail technical requirements - vision scope |  | 1w | 2001-12-21 A | 2001-12-28 A | 23 | 100% |  | 2001-12-21 | 2001-12-28 | 1w |  |  |  |
| 26 | 1.2.2.2 | Detail geographic considerations |  | 1w | 2001-12-21 A | 2001-12-28 A | 23 | 100% |  | 2001-12-21 | 2001-12-28 | 1w |  |  |  |
| 27 | 1.2.2.3 | Detail information architecture/flow |  | 1w | 2001-12-21 A | 2001-12-28 A | 23 | 100% |  | 2001-12-21 | 2001-12-28 | 1w |  |  |  |
| 28 | 1.2.2.4 | Detail application requirements |  | 1w | 2001-12-14 | 2001-12-21 | 23 |  |  | 2001-12-21 | 2001-12-28 | 1w | 110.5d | 5.25d |  |
| 29 | 1.2.2.5 | Detail technology architecture |  | 1w | 2001-12-21 A | 2001-12-28 A | 23 | 100% |  | 2001-12-21 | 2001-12-28 | 1w |  |  |  |
| 30 | 1.2.2.6 | Detail server hardware and software inventory |  | 1w | 2001-12-21 A | 2001-12-28 A | 23 | 100% |  | 2001-12-21 | 2001-12-28 | 1w |  |  |  |
| 31 | 1.2.2.7 | Detail current and future information technology standards |  | 1w | 2001-12-14 | 2001-12-21 | 23 |  |  | 2001-12-21 | 2001-12-28 | 1w | 110.5d | 5.25d |  |
| 32 | 1.2.2.8 | Document current computing environment |  | 1w | 2001-12-28 | 2002-01-04 | 25, 26, 27, 28, 29, 31, 30 |  |  | 2001-12-28 | 2002-01-04 | 1w | 105.25d | 0d |  |
| 33 | 1.2.2.9 | Detail current computing environment complete | milestone | 0d | 2002-01-04 | 2002-01-04 | 32 |  |  | 2002-01-04 | 2002-01-04 | 0d | 105.25d |  |  |

Notes:
- 1: This Microsoft Project 2000 Deployment Template is designed to facilitate the deployment of Microsoft Windows 2000 in a corporate environment. The template is designed to focus the implementation organization on key steps that can ensure a successful, well-planned implementation.
- 2: The first step in planning your deployment is to define your project objectives. In this step, you identify the specific business goals you want to achieve and the way Windows 2000 can help you achieve them. This strategy will also help you choose the most useful Windows 2000 features.
- 11: During this phase, you should develop a functional design specification for each Windows 2000 feature you want to deploy. Your test lab becomes very important during this phase as you test various configurations to determine how to use Windows 2000 features to meet your project objectives.
- 14: Steve
- 15: Steve/Janet
- 16: Definition of best practice and procedure would lie with core team. Departmental liason will refine and tailor base procedures and practices. Also responsible for user education and training.
- 18: Rob Urqhart
- 20: Steve
- 21: Steve/Janet
- 27: In this context, this is information that flows into Active Directory and consists of user and computer data. User data stems from Amaint, while computer data stems from Departmental Admins

| ID | WBS | Task | Type | Duration | Start | Finish | Predecessors | Complete | Remaining | Baseline start | Baseline finish | Baseline duration | Total slack | Free slack | Constraint |
| --- | --- | --- | --- | --- | --- | --- | --- | --- | --- | --- | --- | --- | --- | --- | --- |
| 34 | 1.2.3 | **Identify Coexistence Strategies** |  | 3d | 2001-12-14 | 2001-12-19 |  |  |  | 2001-12-21 | 2001-12-26 | 3d | 0d |  | as late as possible |
| 35 | 1.2.3.1 | Identify interoperability issues within the company (operating systems supported, topology, protocol, etc.) |  | 3d | 2001-12-14 | 2001-12-19 |  |  |  | 2001-12-21 | 2001-12-26 | 3d | 35.75d | 0d |  |
| 36 | 1.2.3.2 | Identify coexistence strategies complete | milestone | 0d | 2001-12-19 | 2001-12-19 | 35 |  |  | 2001-12-26 | 2001-12-26 | 0d | 35.75d | 33.75d |  |
| 37 | 1.2.4 | **Establish Test Lab Environment** |  | 31.5d | 2001-12-21 A | 2002-02-05 |  | 93% | 2.34d | 2001-12-21 | 2002-02-05 | 31.5d | 0d |  | as late as possible |
| 38 | 1.2.4.1 | Review current configuration documents and define a lab model |  | 2d | 2001-12-21 A | 2001-12-25 A |  | 100% |  | 2001-12-21 | 2001-12-25 | 2d |  |  |  |
| 39 | 1.2.4.2 | Select one or more lab locations |  | 1d | 2001-12-25 A | 2001-12-26 A | 38 | 100% |  | 2001-12-25 | 2001-12-26 | 1d |  |  |  |
| 40 | 1.2.4.3 | Determine lab space and environmental requirements |  | 1d | 2001-12-26 A | 2001-12-27 A | 39 | 100% |  | 2001-12-26 | 2001-12-27 | 1d |  |  |  |
| 41 | 1.2.4.4 | Determine power and network connection requirements |  | 2d | 2001-12-27 A | 2001-12-31 A | 40 | 100% |  | 2001-12-27 | 2001-12-31 | 2d |  |  |  |
| 42 | 1.2.4.5 | Design and document logical and physical configuration for the lab |  | 2d | 2001-12-31 A | 2002-01-02 | 41 | 50% | 1d | 2001-12-31 | 2002-01-02 | 2d | 0d |  |  |
| 43 | 1.2.4.6 | Determine hardware requirements |  | 2d | 2002-01-02 A | 2002-01-04 A | 42 | 100% |  | 2002-01-02 | 2002-01-04 | 2d |  |  |  |
| 44 | 1.2.4.7 | Determine software requirements, including business applications and tools |  | 3d | 2002-01-04 A | 2002-01-09 A | 43 | 100% |  | 2002-01-04 | 2002-01-09 | 3d |  |  |  |
| 45 | 1.2.4.8 | Determine who needs to use the lab |  | 1d | 2002-01-09 A | 2002-01-10 A | 44 | 100% |  | 2002-01-09 | 2002-01-10 | 1d |  |  |  |
| 46 | 1.2.4.9 | Determine Amaint requirements |  | 1d | 2002-01-10 A | 2002-01-11 | 45 | 75% | 0.25d | 2002-01-10 | 2002-01-11 | 1d | 0d |  |  |
| 47 | 1.2.4.10 | Determine wiring and network tap plans |  | 1d | 2002-01-11 A | 2002-01-14 A | 46 | 100% |  | 2002-01-11 | 2002-01-14 | 1d |  |  |  |
| 48 | 1.2.4.11 | Acquire hardware, including cables and software |  | 3d | 2002-01-14 A | 2002-01-17 A | 47 | 100% |  | 2002-01-14 | 2002-01-17 | 3d |  |  |  |
| 49 | 1.2.4.12 | Acquire workspace equipment, such as desks, chairs, white boards, cork boards, lamps, telephones, and shelving |  | 3d | 2002-01-14 A | 2002-01-17 A | 47 | 100% |  | 2002-01-14 | 2002-01-17 | 3d |  |  |  |
| 50 | 1.2.4.13 | Build and configure the network |  | 3d | 2002-01-17 A | 2002-01-22 A | 48, 49 | 100% |  | 2002-01-17 | 2002-01-22 | 3d |  |  |  |
| 51 | 1.2.4.14 | Test network connectivity |  | 1d | 2002-01-22 A | 2002-01-23 A | 50 | 100% |  | 2002-01-22 | 2002-01-23 | 1d |  |  |  |
| 52 | 1.2.4.15 | Build and configure the servers |  | 2d | 2002-01-23 A | 2002-01-25 A | 51 | 100% |  | 2002-01-23 | 2002-01-25 | 2d |  |  |  |
| 53 | 1.2.4.16 | Install applications and build databases on the servers |  | 2d | 2002-01-25 A | 2002-01-29 A | 52 | 100% |  | 2002-01-25 | 2002-01-29 | 2d |  |  |  |
| 54 | 1.2.4.17 | Install testing and administrative tools |  | 4h | 2002-01-25 A | 2002-01-28 A | 52 | 100% |  | 2002-01-25 | 2002-01-28 | 4h |  |  |  |
| 55 | 1.2.4.18 | Build and configure the client computers |  | 2d | 2002-01-25 A | 2002-01-29 A | 52 | 100% |  | 2002-01-25 | 2002-01-29 | 2d |  |  |  |
| 56 | 1.2.4.19 | Test all the lab components |  | 2d | 2002-01-29 A | 2002-01-31 A | 54, 53 | 100% |  | 2002-01-29 | 2002-01-31 | 2d |  |  |  |
| 57 | 1.2.4.20 | Define a change control process for the lab |  | 4h | 2002-01-31 | 2002-02-01 | 56 |  |  | 2002-01-31 | 2002-02-01 | 4h | 1d | 0d |  |
| 58 | 1.2.4.21 | Create, test, and document the lab restore process |  | 2d | 2002-02-01 A | 2002-02-05 | 57 | 50% | 1d | 2002-02-01 | 2002-02-05 | 2d | 0d |  |  |
| 59 | 1.2.4.22 | Establish test lab environment complete | milestone | 0d | 2002-01-21 | 2002-01-21 | 58 |  |  | 2002-02-05 | 2002-02-05 | 0d | -10.75d | 0d |  |

| ID | WBS | Task | Type | Duration | Start | Finish | Predecessors | Complete | Remaining | Baseline start | Baseline finish | Baseline duration | Total slack | Free slack | Constraint |
| --- | --- | --- | --- | --- | --- | --- | --- | --- | --- | --- | --- | --- | --- | --- | --- |
| 60 | 1.2.5 | **Perform Risk Assessment** |  | 12d | 2002-02-05 A | 2002-02-21 |  | 17% | 10d | 2002-02-05 | 2002-02-21 | 12d | 0d |  | as late as possible |
| 61 | 1.2.5.1 | Identify mission critical applications |  | 2d | 2002-02-05 | 2002-02-07 | 59, 36 |  |  | 2002-02-05 | 2002-02-07 | 2d | 2d | 0d |  |
| 62 | 1.2.5.2 | Identify and analyze potential risks |  | 4d | 2002-02-07 A | 2002-02-13 | 61 | 50% | 2d | 2002-02-07 | 2002-02-13 | 4d | 0d |  |  |
| 63 | 1.2.5.3 | Quantify potential impact of the risk |  | 2d | 2002-02-13 | 2002-02-15 | 62 |  |  | 2002-02-13 | 2002-02-15 | 2d | 1d | 0d |  |
| 64 | 1.2.5.4 | Detail escalation processes |  | 2d | 2002-02-15 | 2002-02-19 | 63 |  |  | 2002-02-15 | 2002-02-19 | 2d | 1d | 0d |  |
| 65 | 1.2.5.5 | Document risk assessment |  | 2d | 2002-02-19 | 2002-02-21 | 64 |  |  | 2002-02-19 | 2002-02-21 | 2d | 1d | 0d |  |
| 66 | 1.2.5.6 | Risk assessment complete | milestone | 0d | 2002-02-21 | 2002-02-21 | 65 |  |  | 2002-02-21 | 2002-02-21 | 0d | 1d | 0d |  |
| 67 | 1.2.6 | **Define Communication Strategy** |  | 13d | 2001-12-14 | 2002-01-02 |  |  |  | 2001-12-21 | 2002-01-09 | 13d | 0d |  | as late as possible |
| 68 | 1.2.6.1 | Define communication strategy for each phase |  | 3d | 2001-12-14 | 2001-12-19 |  |  |  | 2001-12-21 | 2001-12-26 | 3d | 36.75d | 0d |  |
| 69 | 1.2.6.2 | Define audiences |  | 1d | 2001-12-19 | 2001-12-20 | 68 |  |  | 2001-12-26 | 2001-12-27 | 1d | 36.75d | 0d |  |
| 70 | 1.2.6.3 | Define communication delivery mechanism |  | 3d | 2001-12-20 | 2001-12-25 | 69 |  |  | 2001-12-27 | 2002-01-01 | 3d | 36.75d | 0d |  |
| 71 | 1.2.6.4 | Establish communication timeline |  | 4d | 2001-12-25 | 2001-12-31 | 70 |  |  | 2002-01-01 | 2002-01-07 | 4d | 36.75d | 0d |  |
| 72 | 1.2.6.5 | Document communications strategy/standards |  | 2d | 2001-12-31 | 2002-01-02 | 71 |  |  | 2002-01-07 | 2002-01-09 | 2d | 36.75d | 0d |  |
| 73 | 1.2.6.6 | Communication complete | milestone | 0d | 2002-01-02 | 2002-01-02 | 72 |  |  | 2002-01-09 | 2002-01-09 | 0d | 36.75d | 35.75d |  |
| 74 | 1.2.7 | **Define Education/Training Strategy** |  | 9d | 2001-12-14 | 2001-12-27 |  |  |  | 2001-12-21 | 2002-01-03 | 9d | 0d |  | as late as possible |
| 75 | 1.2.7.1 | Define education strategy for deployment demographics (admins, help desk, end-users) |  | 2d | 2001-12-14 | 2001-12-18 |  |  |  | 2001-12-21 | 2001-12-25 | 2d | 40.75d | 0d |  |
| 76 | 1.2.7.2 | Define education delivery mechanism |  | 2d | 2001-12-18 | 2001-12-20 | 75 |  |  | 2001-12-25 | 2001-12-27 | 2d | 40.75d | 0d |  |
| 77 | 1.2.7.3 | Establish education timeline by phase |  | 3d | 2001-12-20 | 2001-12-25 | 76 |  |  | 2001-12-27 | 2002-01-01 | 3d | 40.75d | 0d |  |
| 78 | 1.2.7.4 | Document education strategy/standards |  | 2d | 2001-12-25 | 2001-12-27 | 77 |  |  | 2002-01-01 | 2002-01-03 | 2d | 40.75d | 0d |  |
| 79 | 1.2.7.5 | Education complete | milestone | 0d | 2001-12-27 | 2001-12-27 | 78 |  |  | 2002-01-03 | 2002-01-03 | 0d | 40.75d | 39.75d |  |
| 80 | 1.2.8 | Planning complete | milestone | 0d | 2002-02-21 | 2002-02-21 | 79, 73, 66 |  |  | 2002-02-21 | 2002-02-21 | 0d | 1d | 0d |  |
| 81 | 1.3 | **Development** |  | 97.5d | 2001-12-14 A | 2002-04-30 |  | 33% | 65.05d | 2001-12-21 | 2002-04-30 | 92.25d | 0d |  | as late as possible |
| 82 | 1.3.1 | **Evaluate Migration Strategies** |  | 7d | 2002-02-21 A | 2002-03-04 |  | 43% | 4d | 2002-02-21 | 2002-03-04 | 7d | 0d |  | as late as possible |
| 83 | 1.3.1.1 | Determine your migration roadmap |  | 1d | 2002-02-21 | 2002-02-22 | 80 |  |  | 2002-02-21 | 2002-02-22 | 1d | 1d | 0d |  |
| 84 | 1.3.1.2 | Determine supported upgrade paths |  | 2d | 2002-02-22 A | 2002-02-26 | 83 | 50% | 1d | 2002-02-22 | 2002-02-26 | 2d | 0d |  |  |
| 85 | 1.3.1.3 | Examine your existing domain structure |  | 2d | 2002-02-26 A | 2002-02-28 A | 84 | 100% |  | 2002-02-26 | 2002-02-28 | 2d |  |  |  |
| 86 | 1.3.1.4 | Develop your recovery plan |  | 2d | 2002-02-28 | 2002-03-04 | 85 |  |  | 2002-02-28 | 2002-03-04 | 2d | 64.75d | 0d |  |
| 87 | 1.3.1.5 | Evaluate migration strategies complete | milestone | 0d | 2002-03-04 | 2002-03-04 | 86 |  |  | 2002-03-04 | 2002-03-04 | 0d | 64.75d |  |  |

Notes:
- 62: Potential Risks / - timeline not met / - account integration doesn't work / - AD does not meet a department's needs / - AD environment is not stable
- 74: Educate your users about Windows 2000 features and functions before you deploy it. You might also want to provide formal training. / Microsoft Official Curriculum (MOC) for Microsoft Windows 2000 Professional and Windows 2000 Server offers computer professionals the expertise to deploy, administer, and support a Windows 2000-based network.
- 81: During the feature development phase, you will create the actual design, sometimes called the functional specification, for the Windows 2000 features that you intend to implement. This phase is when you determine how the features you have selected will actually work in a production environment. The iterative design and testing process starts in this phase as each of your deployment teams creates its own plan and then synchronizes with the deployment team to create a comprehensive design specification. / The technical dependencies of Windows 2000 features first arise during this phase, so it is important that the various deployment specialty teams collaborate and share insight into the capabilities, functionality, and interdependencies of each feature. The project plan contains the functional specification (combined plans of each team) and a schedule. The project plan approved milestone is permission from management to proceed with the deployment. / The tasks in this phase focus the team on areas requiring attention in development.

| ID | WBS | Task | Type | Duration | Start | Finish | Predecessors | Complete | Remaining | Baseline start | Baseline finish | Baseline duration | Total slack | Free slack | Constraint |
| --- | --- | --- | --- | --- | --- | --- | --- | --- | --- | --- | --- | --- | --- | --- | --- |
| 88 | 1.3.2 | **Active Directory** |  | 97.5d | 2001-12-14 A | 2002-04-30 |  | 80% | 19.45d | 2001-12-21 | 2002-04-30 | 92.25d | 0d |  | as late as possible |
| 89 | 1.3.2.1 | **Active Directory and Domain Namespace** |  | 41.75d | 2002-03-04 A | 2002-04-30 |  | 80% | 8.33d | 2002-03-04 | 2002-04-30 | 41.75d | 0d |  | as late as possible |
| 90 | 1.3.2.1.1 | Review Active Directory features |  | 3d | 2002-03-04 A | 2002-03-07 A | 87 | 100% |  | 2002-03-04 | 2002-03-07 | 3d |  |  |  |
| 91 | 1.3.2.1.2 | **Design Active Directory Forest Plan** |  | 38.75d | 2002-03-07 A | 2002-04-30 |  | 79% | 8.27d | 2002-03-07 | 2002-04-30 | 38.75d | 0d |  | as late as possible |
| 92 | 1.3.2.1.2.1 | Determine the number of forests for the network |  | 2d | 2002-03-07 A | 2002-03-11 A | 90 | 100% |  | 2002-03-07 | 2002-03-11 | 2d |  |  |  |
| 93 | 1.3.2.1.2.2 | Define a forest change control policy |  | 2d | 2002-03-11 | 2002-03-13 | 92 |  |  | 2002-03-11 | 2002-03-13 | 2d | 54.75d | 0d |  |
| 94 | 1.3.2.1.2.3 | **Document Impact Considerations of Changes to Forest after Deployment** |  | 3d | 2002-03-13 | 2002-03-18 |  |  |  | 2002-03-13 | 2002-03-18 | 3d | 0d |  | as late as possible |
| 95 | 1.3.2.1.2.3.1 | Define schema change policy |  | 2d | 2002-03-13 | 2002-03-15 | 93 |  |  | 2002-03-13 | 2002-03-15 | 2d | 54.75d | 0d |  |
| 96 | 1.3.2.1.2.3.2 | Define configuration change policy |  | 1d | 2002-03-15 | 2002-03-18 | 95 |  |  | 2002-03-15 | 2002-03-18 | 1d | 54.75d | 0d |  |
| 97 | 1.3.2.1.2.3.3 | Document impact considerations of changes to forest after deployment complete | milestone | 0d | 2002-03-18 | 2002-03-18 | 96 |  |  | 2002-03-18 | 2002-03-18 | 0d | 54.75d |  |  |
| 98 | 1.3.2.1.2.4 | Document forest plan |  | 2d | 2002-03-18 A | 2002-03-20 A | 97 | 100% |  | 2002-03-18 | 2002-03-20 | 2d |  |  |  |
| 99 | 1.3.2.1.2.5 | Design Active Directory forest plan complete | milestone | 0d | 2002-03-20 | 2002-03-20 | 98 |  |  | 2002-03-20 | 2002-03-20 | 0d | 52.75d |  |  |
| 100 | 1.3.2.1.2.6 | **Design Active Directory Domain Plan** |  | 12d | 2002-03-20 A | 2002-04-05 |  | 88% | 1.5d | 2002-03-20 | 2002-04-05 | 12d | 0d |  | as late as possible |
| 101 | 1.3.2.1.2.6.1 | **Determine the Number of Domains in Each Forest** |  | 5d | 2002-03-20 A | 2002-03-27 A |  | 100% |  | 2002-03-20 | 2002-03-27 | 5d |  |  | as late as possible |
| 102 | 1.3.2.1.2.6.1.1 | Evaluate single-domain model |  | 3d | 2002-03-20 A | 2002-03-25 A | 99 | 100% |  | 2002-03-20 | 2002-03-25 | 3d |  |  |  |
| 103 | 1.3.2.1.2.6.1.2 | **Evaluate Multiple Domains Model** |  | 2d | 2002-03-25 A | 2002-03-27 A |  | 100% |  | 2002-03-25 | 2002-03-27 | 2d |  |  | as late as possible |
| 104 | 1.3.2.1.2.6.1.2.1 | Evaluate preserving existing Windows NT 4.0 domains |  | 2d | 2002-03-25 A | 2002-03-27 A | 102, 99 | 100% |  | 2002-03-25 | 2002-03-27 | 2d |  |  |  |
| 105 | 1.3.2.1.2.6.1.2.2 | Evaluate administrative partitioning considerations |  | 2d | 2002-03-25 A | 2002-03-27 A | 102 | 100% |  | 2002-03-25 | 2002-03-27 | 2d |  |  |  |
| 106 | 1.3.2.1.2.6.1.2.3 | Evaluate physical partitioning considerations |  | 2d | 2002-03-25 A | 2002-03-27 A | 102 | 100% |  | 2002-03-25 | 2002-03-27 | 2d |  |  |  |
| 107 | 1.3.2.1.2.6.1.2.4 | Multiple domains model complete | milestone | 0d | 2002-03-27 A | 2002-03-27 A | 106, 104, 105 | 100% |  | 2002-03-27 | 2002-03-27 | 0d |  |  |  |
| 108 | 1.3.2.1.2.6.2 | Assign a forest root domain |  | 4h | 2002-03-27 A | 2002-03-27 A | 102, 107 | 100% |  | 2002-03-27 | 2002-03-27 | 4h |  |  |  |
| 109 | 1.3.2.1.2.6.3 | Assign a Domain Name System (DNS) name to each domain to create domain hierarchy |  | 4h | 2002-03-27 A | 2002-03-28 A | 108 | 100% |  | 2002-03-27 | 2002-03-28 | 4h |  |  |  |
| 110 | 1.3.2.1.2.6.4 | Plan a DNS server deployment |  | 2d | 2002-03-28 A | 2002-04-01 A | 109 | 100% |  | 2002-03-28 | 2002-04-01 | 2d |  |  |  |
| 111 | 1.3.2.1.2.6.5 | Optimize authentication with shortcut trusts |  | 2d | 2002-04-01 A | 2002-04-03 A | 110 | 100% |  | 2002-04-01 | 2002-04-03 | 2d |  |  |  |
| 112 | 1.3.2.1.2.6.6 | Document impact considerations of changes to domain after deployment |  | 2d | 2002-04-03 | 2002-04-05 | 111 |  |  | 2002-04-03 | 2002-04-05 | 2d | 40.75d | 0d |  |
| 113 | 1.3.2.1.2.6.7 | Design Active Directory domain plan complete | milestone | 0d | 2002-04-05 | 2002-04-05 | 112 |  |  | 2002-04-05 | 2002-04-05 | 0d | 40.75d |  |  |

Notes:
- 89: Your Active Directory structure and Domain Name System (DNS), along with your infrastructure plans for WINS, DHCP, network protocols, files, printing, streaming media, and other bandwidth intensive applications, must be designed to accommodate business requirements and information technology (IT) capabilities. If your business includes numerous subsidiaries and roaming or remote access users, then you need to consider organizational units, group policy, security, and IntelliMirror technologies. If you want to offer secure intranet or extranet capabilities, then IPSec and public key infrastructure (PKI) become important components to design. / If you will be deploying Windows 2000 Professional as your primary operating system for desktops and laptops, then you will want to consider installation options, multilanguage capabilities, security, Active Directory, and other change and configuration management technologies. Finally, if you are in a heterogeneous environment that includes network operating systems other than Windows NT or Windows 2000, you will need to consider interoperability and coexistence options.

| ID | WBS | Task | Type | Duration | Start | Finish | Predecessors | Complete | Remaining | Baseline start | Baseline finish | Baseline duration | Total slack | Free slack | Constraint |
| --- | --- | --- | --- | --- | --- | --- | --- | --- | --- | --- | --- | --- | --- | --- | --- |
| 114 | 1.3.2.1.2.7 | **Design Active Directory Organizational Unit (OU) Plan** |  | 6d | 2002-04-05 A | 2002-04-15 |  | 67% | 2d | 2002-04-05 | 2002-04-15 | 6d | 0d |  | as late as possible |
| 115 | 1.3.2.1.2.7.1 | Define OUs to delegate administration |  | 2d | 2002-04-05 A | 2002-04-09 A | 113 | 100% |  | 2002-04-05 | 2002-04-09 | 2d |  |  |  |
| 116 | 1.3.2.1.2.7.2 | Define OUs to hide objects |  | 1d | 2002-04-09 A | 2002-04-10 A | 115 | 100% |  | 2002-04-09 | 2002-04-10 | 1d |  |  |  |
| 117 | 1.3.2.1.2.7.3 | Define OUs to apply Group Policy |  | 1d | 2002-04-10 A | 2002-04-11 A | 116 | 100% |  | 2002-04-10 | 2002-04-11 | 1d |  |  |  |
| 118 | 1.3.2.1.2.7.4 | Document impact considerations of changes to OU structures after deployment |  | 2d | 2002-04-11 | 2002-04-15 | 117 |  |  | 2002-04-11 | 2002-04-15 | 2d | 34.75d | 0d |  |
| 119 | 1.3.2.1.2.7.5 | Design Active Directory OU plan complete | milestone | 0d | 2002-04-15 | 2002-04-15 | 118 |  |  | 2002-04-15 | 2002-04-15 | 0d | 34.75d |  |  |
| 120 | 1.3.2.1.2.8 | **Design a Site Topology Plan** |  | 11.75d | 2002-04-15 A | 2002-04-30 |  | 99% | 0.12d | 2002-04-15 | 2002-04-30 | 11.75d | 0d |  | as late as possible |
| 121 | 1.3.2.1.2.8.1 | **Define Sites and Site Links Using the Physical Network Topology** |  | 5d | 2002-04-15 A | 2002-04-22 A |  | 100% |  | 2002-04-15 | 2002-04-22 | 5d |  |  | as late as possible |
| 122 | 1.3.2.1.2.8.1.1 | Obtain physical network topology map |  | 4h | 2002-04-15 A | 2002-04-15 A | 119 | 100% |  | 2002-04-15 | 2002-04-15 | 4h |  |  |  |
| 123 | 1.3.2.1.2.8.1.2 | Create site for each LAN or set of LANs connected by high-speed backbone |  | 1d | 2002-04-15 A | 2002-04-16 A | 122 | 100% |  | 2002-04-15 | 2002-04-16 | 1d |  |  |  |
| 124 | 1.3.2.1.2.8.1.3 | Create a site for each location lacking direct connectivity (SMTP mail) |  | 1d | 2002-04-16 A | 2002-04-17 A | 123 | 100% |  | 2002-04-16 | 2002-04-17 | 1d |  |  |  |
| 125 | 1.3.2.1.2.8.1.4 | Record internet protocol (IP) subnets for each site |  | 4h | 2002-04-17 A | 2002-04-18 A | 124 | 100% |  | 2002-04-17 | 2002-04-18 | 4h |  |  |  |
| 126 | 1.3.2.1.2.8.1.5 | **Site Links** |  | 2d | 2002-04-18 A | 2002-04-22 A |  | 100% |  | 2002-04-18 | 2002-04-22 | 2d |  |  | as late as possible |
| 127 | 1.3.2.1.2.8.1.5.1 | Define site connections with site links |  | 1d | 2002-04-18 A | 2002-04-19 A | 125 | 100% |  | 2002-04-18 | 2002-04-19 | 1d |  |  |  |
| 128 | 1.3.2.1.2.8.1.5.2 | Define replication schedules |  | 1d | 2002-04-19 A | 2002-04-22 A | 127 | 100% |  | 2002-04-19 | 2002-04-22 | 1d |  |  |  |
| 129 | 1.3.2.1.2.8.1.5.3 | Define replication intervals | milestone | 0d | 2002-04-22 A | 2002-04-22 A | 128 | 100% |  | 2002-04-22 | 2002-04-22 | 0d |  |  |  |
| 130 | 1.3.2.1.2.8.1.5.4 | Define replication transports | milestone | 0d | 2002-04-22 A | 2002-04-22 A | 129 | 100% |  | 2002-04-22 | 2002-04-22 | 0d |  |  |  |
| 131 | 1.3.2.1.2.8.1.5.5 | Define link costs | milestone | 0d | 2002-04-22 A | 2002-04-22 A | 130 | 100% |  | 2002-04-22 | 2002-04-22 | 0d |  |  |  |
| 132 | 1.3.2.1.2.8.1.5.6 | Site links complete | milestone | 0d | 2002-04-22 A | 2002-04-22 A | 131 | 100% |  | 2002-04-22 | 2002-04-22 | 0d |  |  |  |
| 133 | 1.3.2.1.2.8.2 | **Define Server Locations Within Sites** |  | 6.25d | 2002-04-22 A | 2002-04-30 |  | 98% | 0.12d | 2002-04-22 | 2002-04-30 | 6.25d | 0d |  | as late as possible |
| 134 | 1.3.2.1.2.8.2.1 | Define domain controller location per physical partition design |  | 1d | 2002-04-22 A | 2002-04-23 A | 132 | 100% |  | 2002-04-22 | 2002-04-23 | 1d |  |  |  |
| 135 | 1.3.2.1.2.8.2.2 | **Define Additional Domain Controllers** |  | 2d | 2002-04-23 A | 2002-04-25 A |  | 100% |  | 2002-04-23 | 2002-04-25 | 2d |  |  | as late as possible |
| 136 | 1.3.2.1.2.8.2.2.1 | Analyze failover requirements |  | 1d | 2002-04-23 A | 2002-04-24 A | 134 | 100% |  | 2002-04-23 | 2002-04-24 | 1d |  |  |  |
| 137 | 1.3.2.1.2.8.2.2.2 | Analyze domain controller client workload |  | 1d | 2002-04-24 A | 2002-04-25 A | 136 | 100% |  | 2002-04-24 | 2002-04-25 | 1d |  |  |  |
| 138 | 1.3.2.1.2.8.2.2.3 | Define additional domain controllers complete | milestone | 0d | 2002-04-25 A | 2002-04-25 A | 137 | 100% |  | 2002-04-25 | 2002-04-25 | 0d |  |  |  |
| 139 | 1.3.2.1.2.8.2.3 | Define location of global catalog servers |  | 2h | 2002-04-25 A | 2002-04-25 | 138 | 50% | 1h | 2002-04-25 | 2002-04-25 | 2h | 0d |  |  |
| 140 | 1.3.2.1.2.8.2.4 | Define co existence with DNS servers |  | 3d | 2002-04-25 A | 2002-04-30 A | 139 | 100% |  | 2002-04-25 | 2002-04-30 | 3d |  |  |  |
| 141 | 1.3.2.1.2.8.3 | Document impact considerations of changes to site topology after deployment |  | 4h | 2002-04-30 A | 2002-04-30 A | 140 | 100% |  | 2002-04-30 | 2002-04-30 | 4h |  |  |  |
| 142 | 1.3.2.1.2.8.4 | Design a site topology plan complete | milestone | 0d | 2002-04-30 A | 2002-04-30 A | 141 | 100% |  | 2002-04-30 | 2002-04-30 | 0d |  |  |  |
| 143 | 1.3.2.2 | Active Directory complete | milestone | 0d | 2001-12-14 | 2001-12-14 |  |  |  | 2001-12-21 | 2001-12-21 | 0d | 15.5d | 0d |  |

| ID | WBS | Task | Type | Duration | Start | Finish | Predecessors | Complete | Remaining | Baseline start | Baseline finish | Baseline duration | Total slack | Free slack | Constraint |
| --- | --- | --- | --- | --- | --- | --- | --- | --- | --- | --- | --- | --- | --- | --- | --- |
| 144 | 1.3.3 | **Security Considerations** |  | 57d | 2001-12-21 A | 2002-03-12 |  | 16% | 47.7d | 2001-12-21 | 2002-03-12 | 57d | 0d |  | as late as possible |
| 145 | 1.3.3.1 | Identify the security risks that apply to your network |  | 1w | 2001-12-21 A | 2001-12-28 A | 143 | 100% |  | 2001-12-21 | 2001-12-28 | 1w |  |  |  |
| 146 | 1.3.3.2 | Assess solutions for identifiable security risks |  | 3d | 2001-12-28 | 2002-01-02 | 145 |  |  | 2001-12-28 | 2002-01-02 | 3d | 0.8d | 0d |  |
| 147 | 1.3.3.3 | Ensure that all access to network resources requires authentication using domain accounts |  | 2d | 2002-01-02 | 2002-01-04 | 146 |  |  | 2002-01-02 | 2002-01-04 | 2d | 0.8d | 0d |  |
| 148 | 1.3.3.4 | Define the password length, change interval, and complexity requirements for domain user accounts, and develop a plan to communicate these requirements to the user community |  | 1d | 2002-01-04 | 2002-01-07 | 147 |  |  | 2002-01-04 | 2002-01-07 | 1d | 0.8d | 0d |  |
| 149 | 1.3.3.5 | Define policy for enabling remote access services |  | 2d | 2002-01-07 | 2002-01-09 | 148 |  |  | 2002-01-07 | 2002-01-09 | 2d | 0.8d | 0d |  |
| 150 | 1.3.3.6 | Develop procedures/communication regarding remote access procedures, including connection methods |  | 2d | 2002-01-09 | 2002-01-11 | 149 |  |  | 2002-01-09 | 2002-01-11 | 2d | 0.8d | 0d |  |
| 151 | 1.3.3.7 | Define user groups and establish conventions for group names and how group types are used |  | 3d | 2002-01-11 | 2002-01-16 | 150 |  |  | 2002-01-11 | 2002-01-16 | 3d | 0.8d | 0d |  |
| 152 | 1.3.3.8 | Define the top-level security groups you intend to use for broad security access to enterprise-wide resources |  | 1d | 2002-01-16 | 2002-01-17 | 151 |  |  | 2002-01-16 | 2002-01-17 | 1d | 0.8d | 0d |  |
| 153 | 1.3.3.9 | Define your access control policies with specific reference to how security groups are used |  | 2d | 2002-01-17 A | 2002-01-21 | 152 | 40% | 1.2d | 2002-01-17 | 2002-01-21 | 2d | 0d |  |  |
| 154 | 1.3.3.10 | Define the procedures for creating new groups and who will have responsibility to manage group membership |  | 1d | 2002-01-21 A | 2002-01-22 | 153 | 50% | 0.5d | 2002-01-21 | 2002-01-22 | 1d | 0d |  |  |
| 155 | 1.3.3.11 | Identify which existing domains belong in the forest and which domains will use external trust relationships |  | 1d | 2002-01-22 A | 2002-01-23 A | 154 | 100% |  | 2002-01-22 | 2002-01-23 | 1d |  |  |  |
| 156 | 1.3.3.12 | Describe your domains, domain trees, and forests, and explicitly state the trust relationships among them |  | 1d | 2002-01-23 A | 2002-01-24 A | 155 | 100% |  | 2002-01-23 | 2002-01-24 | 1d |  |  |  |
| 157 | 1.3.3.13 | Develop a deployment plan for using Internet Protocol Security (IPSec) for protection data for remote access or for accessing sensitive application data servers |  | 2d | 2002-01-24 | 2002-01-28 | 156 |  |  | 2002-01-24 | 2002-01-28 | 2d | 66.25d | 0d |  |
| 158 | 1.3.3.14 | If using Encrypting File System (EFS), describe your data recovery policy, including the role of recovery agent in your organization |  | 2d | 2002-01-28 | 2002-01-30 | 157 |  |  | 2002-01-28 | 2002-01-30 | 2d | 66.25d | 0d |  |
| 159 | 1.3.3.15 | If using EFS, describe the procedures you will use to implement data recovery process and verify the process works for your organization |  | 2d | 2002-01-30 | 2002-02-01 | 158 |  |  | 2002-01-30 | 2002-02-01 | 2d | 66.25d | 0d |  |
| 160 | 1.3.3.16 | If using IPSec, identify the scenarios for the way it will be used in your network and understand the performance implications |  | 2d | 2002-02-01 | 2002-02-05 | 159 |  |  | 2002-02-01 | 2002-02-05 | 2d | 66.25d | 0d |  |
| 161 | 1.3.3.17 | Define/communicate domain-wide account policies |  | 3d | 2002-02-05 | 2002-02-08 | 160 |  |  | 2002-02-05 | 2002-02-08 | 3d | 66.25d | 0d |  |
| 162 | 1.3.3.18 | Determine the local security policy requirements for different categories of systems on the network, such as desktops, file and print servers, e-mail servers, and define the Group Policy security settings appropriate to each category |  | 3d | 2002-02-08 | 2002-02-13 | 161 |  |  | 2002-02-08 | 2002-02-13 | 3d | 66.25d | 0d |  |
| 163 | 1.3.3.19 | Define application servers where specific security templates can be used to manage security settings, and consider managing them through Group Policy |  | 2d | 2002-02-13 | 2002-02-15 | 162 |  |  | 2002-02-13 | 2002-02-15 | 2d | 66.25d | 0d |  |
| 164 | 1.3.3.20 | Apply appropriate security templates for systems that upgrade from Windows NT 4.0 instead of a clean install |  | 1d | 2002-02-15 | 2002-02-18 | 163 |  |  | 2002-02-15 | 2002-02-18 | 1d | 66.25d | 0d |  |
| 165 | 1.3.3.21 | Use security templates as a means of describing the level of security you intend to implement for different classes of computers |  | 1d | 2002-02-18 | 2002-02-19 | 164 |  |  | 2002-02-18 | 2002-02-19 | 1d | 66.25d | 0d |  |
| 166 | 1.3.3.22 | Develop a test plan to verify your common business applications run correctly under properly configured secure systems |  | 1w | 2002-02-19 | 2002-02-26 | 165 |  |  | 2002-02-19 | 2002-02-26 | 1w | 66.25d | 0d |  |
| 167 | 1.3.3.23 | Define what additional applications are needed that provide enhanced security features to meet your organization security objectives |  | 1d | 2002-02-26 | 2002-02-27 | 166 |  |  | 2002-02-26 | 2002-02-27 | 1d | 66.25d | 0d |  |
| 168 | 1.3.3.24 | State your policies for securing the administrator account and the administration consoles |  | 1d | 2002-02-27 | 2002-02-28 | 167 |  |  | 2002-02-27 | 2002-02-28 | 1d | 66.25d |  |  |
| 169 | 1.3.3.25 | Identify the situations where you plan to delegate administrator control for specific tasks |  | 1d | 2002-02-28 A | 2002-03-01 A | 168 | 100% |  | 2002-02-28 | 2002-03-01 | 1d |  |  |  |
| 170 | 1.3.3.26 | Identify your policies regarding auditing, including staffing |  | 2d | 2002-01-10 | 2002-01-11 | 169 |  |  | 2002-03-01 | 2002-03-05 | 2d | -36.75d | 0d |  |
| 171 | 1.3.3.27 | Document security strategy/standards |  | 1w | 2002-01-14 | 2002-01-18 | 170 |  |  | 2002-03-05 | 2002-03-12 | 1w | -36.75d | 0d |  |
| 172 | 1.3.3.28 | Security considerations complete | milestone | 0d | 2002-01-21 | 2002-01-21 | 171 |  |  | 2002-03-12 | 2002-03-12 | 0d | -36.75d | 0d |  |

Notes:
- 154: Most groups will be auto-created by Amaint. Departmental admins will be able to manage groups within their own OUs, completely on their own.
- 155: No existing domains will be brought into the forest
- 167: Anti-virus scanners, etc

| ID | WBS | Task | Type | Duration | Start | Finish | Predecessors | Baseline start | Baseline finish | Baseline duration | Total slack | Free slack | Constraint |
| --- | --- | --- | --- | --- | --- | --- | --- | --- | --- | --- | --- | --- | --- |
| 173 | 1.3.4 | **Terminal Services** |  | 10d | 2001-12-14 | 2001-12-28 |  | 2001-12-21 | 2002-01-04 | 10d | 0d |  | as late as possible |
| 174 | 1.3.4.1 | Select remote administration or server application mode |  | 2d | 2001-12-14 | 2001-12-18 | 143 | 2001-12-21 | 2001-12-25 | 2d | 15.5d | 0d |  |
| 175 | 1.3.4.2 | Develop a plan for implementing Terminal Services including networking, security, and remote access |  | 3d | 2001-12-18 | 2001-12-21 | 174 | 2001-12-25 | 2001-12-28 | 3d | 15.5d | 0d |  |
| 176 | 1.3.4.3 | Document detailed Terminal Services strategy/standards |  | 1w | 2001-12-21 | 2001-12-28 | 175 | 2001-12-28 | 2002-01-04 | 1w | 15.5d | 0d |  |
| 177 | 1.3.4.4 | Terminal Services complete | milestone | 0d | 2001-12-28 | 2001-12-28 | 176 | 2002-01-04 | 2002-01-04 | 0d | 15.5d |  |  |
| 178 | 1.3.5 | **Storage Management Strategies** |  | 9.5d | 2001-12-14 | 2001-12-27 |  | 2001-12-21 | 2002-01-04 | 9.5d | 0d |  | as late as possible |
| 179 | 1.3.5.1 | **Evaluate Windows 2000 Disk Management Strategies** |  | 1d | 2001-12-14 | 2001-12-17 |  | 2001-12-21 | 2001-12-24 | 1d | 0d |  | as late as possible |
| 180 | 1.3.5.1.1 | Basic storage |  | 4h | 2001-12-14 | 2001-12-14 |  | 2001-12-21 | 2001-12-24 | 4h | 0d |  |  |
| 181 | 1.3.5.1.2 | Dynamic storage |  | 4h | 2001-12-17 | 2001-12-17 | 180 | 2001-12-24 | 2001-12-24 | 4h | 0d |  |  |
| 182 | 1.3.5.2 | Evaluate volume management |  | 1d | 2001-12-17 | 2001-12-18 | 181 | 2001-12-24 | 2001-12-25 | 1d | 0d |  |  |
| 183 | 1.3.5.3 | Evaluate mount points |  | 2d | 2001-12-18 | 2001-12-20 | 182 | 2001-12-25 | 2001-12-27 | 2d | 0d |  |  |
| 184 | 1.3.5.4 | Evaluate disk defragmentation strategies |  | 4h | 2001-12-20 | 2001-12-20 | 183 | 2001-12-27 | 2001-12-28 | 4h | 0d |  |  |
| 185 | 1.3.5.5 | Evaluate removable storage strategies |  | 1d | 2001-12-21 | 2001-12-21 | 184 | 2001-12-28 | 2001-12-31 | 1d | 0d |  |  |
| 186 | 1.3.5.6 | Evaluate remote storage strategies |  | 1d | 2001-12-24 | 2001-12-24 | 185 | 2001-12-31 | 2002-01-01 | 1d | 0d |  |  |
| 187 | 1.3.5.7 | Document storage management strategy/standards |  | 3d | 2001-12-25 | 2001-12-27 | 186 | 2002-01-01 | 2002-01-04 | 3d | 0d |  |  |
| 188 | 1.3.5.8 | Storage management strategies complete | milestone | 0d | 2001-12-27 | 2001-12-27 | 187 | 2002-01-04 | 2002-01-04 | 0d | 0d |  |  |
| 189 | 1.3.6 | **Remediate Risk Assessment** |  | 7d | 2001-12-28 | 2002-01-07 |  | 2002-01-04 | 2002-01-15 | 7d | 0d |  | as late as possible |
| 190 | 1.3.6.1 | Review risk assessment document |  | 1d | 2001-12-28 | 2001-12-28 | 188 | 2002-01-04 | 2002-01-07 | 1d | 0d |  |  |
| 191 | 1.3.6.2 | Identify solutions |  | 3d | 2001-12-31 | 2002-01-02 | 190 | 2002-01-07 | 2002-01-10 | 3d | 0d |  |  |
| 192 | 1.3.6.3 | Communicate to project sponsor, senior management, and project members |  | 1d | 2002-01-03 | 2002-01-03 | 191 | 2002-01-10 | 2002-01-11 | 1d | 0d |  |  |
| 193 | 1.3.6.4 | Evaluate risk as part of day-to-day project management |  | 2d | 2002-01-04 | 2002-01-07 | 192 | 2002-01-11 | 2002-01-15 | 2d | 0d |  |  |
| 194 | 1.3.6.5 | Remediate risk assessment complete | milestone | 0d | 2002-01-07 | 2002-01-07 | 193 | 2002-01-15 | 2002-01-15 | 0d | 0d |  |  |
| 195 | 1.3.7 | **Develop Communications** |  | 1.75d | 2002-01-08 | 2002-01-09 |  | 2002-01-15 | 2002-01-16 | 1.75d | 0d |  | as late as possible |
| 196 | 1.3.7.1 | Review communications strategy/standards |  | 2h | 2002-01-08 | 2002-01-08 | 194 | 2002-01-15 | 2002-01-15 | 2h | 7.25d | 0d |  |
| 197 | 1.3.7.2 | Develop communication materials |  | 2h | 2002-01-08 | 2002-01-08 | 196 | 2002-01-15 | 2002-01-15 | 2h | 7.25d | 0d |  |
| 198 | 1.3.7.3 | Review communications materials |  | 2h | 2002-01-08 | 2002-01-08 | 197 | 2002-01-15 | 2002-01-15 | 2h | 7.25d | 0d |  |
| 199 | 1.3.7.4 | Approve communications strategy and materials |  | 1d | 2002-01-08 | 2002-01-09 | 198 | 2002-01-16 | 2002-01-16 | 1d | 7.25d | 0d |  |
| 200 | 1.3.7.5 | Communication complete | milestone | 0d | 2002-01-09 | 2002-01-09 | 199 | 2002-01-16 | 2002-01-16 | 0d | 7.25d |  |  |

| ID | WBS | Task | Type | Duration | Start | Finish | Predecessors | Complete | Remaining | Baseline start | Baseline finish | Baseline duration | Total slack | Free slack | Constraint |
| --- | --- | --- | --- | --- | --- | --- | --- | --- | --- | --- | --- | --- | --- | --- | --- |
| 201 | 1.3.8 | **Develop Education/training** |  | 9d | 2002-01-08 | 2002-01-18 |  |  |  | 2002-01-15 | 2002-01-28 | 9d | 0d |  | as late as possible |
| 202 | 1.3.8.1 | Review training strategy/standards |  | 1d | 2002-01-08 | 2002-01-08 | 194 |  |  | 2002-01-15 | 2002-01-16 | 1d | 0d |  |  |
| 203 | 1.3.8.2 | Develop/acquire training materials |  | 1w | 2002-01-09 | 2002-01-15 | 202 |  |  | 2002-01-16 | 2002-01-23 | 1w | 0d |  |  |
| 204 | 1.3.8.3 | Review education materials |  | 2d | 2002-01-16 | 2002-01-17 | 203 |  |  | 2002-01-23 | 2002-01-25 | 2d | 0d |  |  |
| 205 | 1.3.8.4 | Approve education strategy and materials |  | 1d | 2002-01-18 | 2002-01-18 | 204 |  |  | 2002-01-25 | 2002-01-28 | 1d | 0d |  |  |
| 206 | 1.3.8.5 | Develop training complete | milestone | 0d | 2002-01-18 | 2002-01-18 | 205 |  |  | 2002-01-28 | 2002-01-28 | 0d | 0d |  |  |
| 207 | 1.3.9 | Development complete | milestone | 0d | 2002-01-21 | 2002-01-21 | 206, 200, 177, 172 |  |  | 2002-03-12 | 2002-03-12 | 0d | -36.75d | 0d |  |
| 208 | 1.4 | **Proof of Concept (POC)** |  | 9.5d | 2002-03-12 A | 2002-03-26 |  | 15% | 8.09d | 2001-12-21 | 2002-03-26 | 66.5d | 0d |  | as late as possible |
| 209 | 1.4.1 | **POC Preparation** |  | 7.5d | 2002-03-12 A | 2002-03-22 |  | 17% | 6.21d | 2002-03-12 | 2002-03-18 | 3.5d | 0d |  | as late as possible |
| 210 | 1.4.1.1 | Prepare a test plan and checklists based on development/design solutions |  | 3d | 2002-03-12 | 2002-03-15 | 207 |  |  | 2002-03-12 | 2002-03-15 | 3d | 55.25d |  |  |
| 211 | 1.4.1.2 | Document features and components to test |  | 2d | 2002-03-12 | 2002-03-14 | 207 |  |  | 2002-03-12 | 2002-03-14 | 2d | 56.25d |  |  |
| 212 | 1.4.1.3 | Secure resting personnel |  | 4h | 2002-01-21 | 2002-01-21 | 207 |  |  | 2002-03-12 | 2002-03-13 | 4h | -36.75d | 0d |  |
| 213 | 1.4.1.4 | **Ensure the Testing Lab Environment Simulates the Proposed Production Environment** |  | 7d | 2002-03-13 A | 2002-03-22 | 207, 59, 212 | 20% | 5.6d | 2002-03-13 | 2002-03-18 | 3d | 0d |  | as late as possible |
| 214 | 1.4.1.4.1 | Server hardware and drivers |  | 2d | 2002-03-13 A | 2002-03-15 A | 212 | 100% |  | 2002-03-13 | 2002-03-15 | 2d |  |  |  |
| 215 | 1.4.1.4.2 | Services and configurations |  | 1d | 2002-01-23 | 2002-01-24 | 212 |  |  | 2002-03-13 | 2002-03-14 | 1d | -34.75d | 0d |  |
| 216 | 1.4.1.4.3 | User accounts |  | 1d | 2002-01-23 | 2002-01-24 | 212 |  |  | 2002-03-13 | 2002-03-14 | 1d | -34.75d | 0d |  |
| 217 | 1.4.1.4.4 | Domain structure (simulated domain hierarchy) |  | 2d | 2002-03-13 A | 2002-03-15 A | 212 | 100% |  | 2002-03-13 | 2002-03-15 | 2d |  |  |  |
| 218 | 1.4.1.4.5 | Server function/strategy |  | 2d | 2002-01-22 | 2002-01-24 | 212 |  |  | 2002-03-13 | 2002-03-15 | 2d | -35.75d | 0d |  |
| 219 | 1.4.1.4.6 | Mixed environment |  | 1d | 2002-01-23 | 2002-01-24 | 212 |  |  | 2002-03-13 | 2002-03-14 | 1d | -34.75d | 0d |  |
| 220 | 1.4.1.4.7 | Client computer configuration |  | 2d | 2002-01-22 | 2002-01-24 | 212 |  |  | 2002-03-13 | 2002-03-15 | 2d | -35.75d | 0d |  |
| 221 | 1.4.1.4.8 | Network topology and protocols |  | 2d | 2002-03-13 A | 2002-03-15 A | 212 | 100% |  | 2002-03-13 | 2002-03-15 | 2d |  |  |  |
| 222 | 1.4.1.4.9 | WAN connectivity |  | 2d | 2002-01-22 | 2002-01-24 | 212 |  |  | 2002-03-13 | 2002-03-15 | 2d | -35.75d | 0d |  |
| 223 | 1.4.1.4.10 | Remote connectivity |  | 1d | 2002-01-23 | 2002-01-24 | 212 |  |  | 2002-03-13 | 2002-03-14 | 1d | -34.75d | 0d |  |
| 224 | 1.4.1.4.11 | Peripherals |  | 3d | 2002-01-21 | 2002-01-24 | 212 |  |  | 2002-03-13 | 2002-03-18 | 3d | -36.75d | 0d |  |
| 225 | 1.4.1.4.12 | Amaint Integration | milestone | 7d | 2002-03-13 | 2002-03-22 | 212 |  |  |  |  |  | 50.75d |  |  |
| 226 | 1.4.1.4.13 | Interoperability with other operating systems (UNIX, mainframe, etc.) |  | 1d | 2002-03-13 A | 2002-03-14 | 212 | 60% | 0.4d | 2002-03-13 | 2002-03-18 | 3d | 0d |  |  |
| 227 | 1.4.1.4.14 | Administrative tools |  | 2d | 2002-01-22 | 2002-01-24 | 212 |  |  | 2002-03-13 | 2002-03-14 | 1d | -35.75d | 0d |  |
| 228 | 1.4.1.4.15 | Fault tolerance techniques |  | 2d | 2002-01-22 | 2002-01-24 | 212 |  |  | 2002-03-13 | 2002-03-15 | 2d | -35.75d | 0d |  |
| 229 | 1.4.1.4.16 | Terminal Services |  | 2d | 2002-01-22 | 2002-01-24 | 212 |  |  | 2002-03-13 | 2002-03-15 | 2d | -35.75d | 0d |  |
| 230 | 1.4.1.4.17 | Ensure the testing lab environment simulates the proposed complete | milestone | 0d | 2002-01-24 | 2002-01-24 | 214, 215, 216, 217, 218, 219, 220, 221, 222, 223, 224, 226, 227, 228, 229 |  |  | 2002-03-18 | 2002-03-18 | 0d | -36.75d | 0d |  |
| 231 | 1.4.1.5 | POC preparation complete | milestone | 0d | 2002-01-24 | 2002-01-24 | 230 |  |  | 2002-03-18 | 2002-03-18 | 0d | -36.75d | 0d |  |

Notes:
- 208: During this phase, the proof of concept (POC) environment is created to evaluate the various components discussed earlier in the plan. The POC environment should be a scaled-back version of the full Windows 2000 model for proper evaluation purposes.
- 214: Working within a limited budget, lab machines will resemble production machines (similar speed & memory), but will not contain the same hardware

| ID | WBS | Task | Type | Duration | Start | Finish | Predecessors | Baseline start | Baseline finish | Baseline duration | Total slack | Free slack | Constraint |
| --- | --- | --- | --- | --- | --- | --- | --- | --- | --- | --- | --- | --- | --- |
| 232 | 1.4.2 | **Deploy Development Solution to POC (Production) Machines** |  | 6d | 2002-03-18 | 2002-03-26 |  | 2002-03-18 | 2002-03-26 | 6d | 0d |  | as late as possible |
| 233 | 1.4.2.1 | Perform tests to test plan specification |  | 2d | 2002-01-24 | 2002-01-28 | 231 | 2002-03-18 | 2002-03-20 | 2d | -36.75d | 0d |  |
| 234 | 1.4.2.2 | Analyze results |  | 4d | 2002-01-28 | 2002-02-01 | 233 | 2002-03-20 | 2002-03-26 | 4d | -36.75d | 0d |  |
| 235 | 1.4.3 | POC complete | milestone | 0d | 2002-02-01 | 2002-02-01 | 234 | 2001-12-21 | 2001-12-21 | 0d | -36.75d | 0d |  |
| 236 | 1.5 | **Pilot** |  | 84.75d | 2002-02-01 | 2002-05-31 | 235 | 2001-12-21 | 2002-02-27 | 48d | -36.75d | 0d | as late as possible |
| 237 | 1.5.1 | **Planning** |  | 53.75d | 2002-02-01 | 2002-04-18 |  | 2001-12-21 | 2002-01-15 | 17d | -36.75d | 0d | as late as possible |
| 238 | 1.5.1.1 | Document resources and tasks |  | 2d | 2002-03-26 | 2002-03-28 |  | 2001-12-21 | 2001-12-25 | 2d | 46.75d |  |  |
| 239 | 1.5.1.2 | Ensure POC lab stable |  | 2d | 2002-02-19 | 2002-02-21 |  | 2001-12-21 | 2001-12-25 | 2d | -24.75d | 0d |  |
| 240 | 1.5.1.3 | **Develop the Rollout Process** |  | 17d | 2002-02-01 | 2002-02-26 |  | 2001-12-21 | 2002-01-09 | 13d | -36.75d | 0d | as late as possible |
| 241 | 1.5.1.3.1 | Identify tools and supplies the installer needs |  | 2d | 2002-02-22 | 2002-02-26 | 239 | 2001-12-25 | 2001-12-27 | 2d | -23.75d | 0d |  |
| 242 | 1.5.1.3.2 | Identify lists of scripts and their location |  | 3d | 2002-02-21 | 2002-02-26 | 239 | 2001-12-25 | 2001-12-28 | 3d | -24.75d | 0d |  |
| 243 | 1.5.1.3.3 | Document steps for deploying the new domain structure |  | 3d | 2002-02-01 | 2002-02-06 |  | 2001-12-21 | 2001-12-26 | 3d | -36.75d | 0d |  |
| 244 | 1.5.1.3.4 | Document steps for performing manual and automated computer upgrades |  | 2d | 2002-02-06 | 2002-02-08 | 243 | 2001-12-26 | 2001-12-28 | 2d | -36.75d | 0d |  |
| 245 | 1.5.1.3.5 | Document QA procedure |  | 2d | 2002-02-08 | 2002-02-12 | 244 | 2001-12-28 | 2002-01-01 | 2d | -36.75d | 0d |  |
| 246 | 1.5.1.3.6 | Document operational procedures installers and administrators are to perform (resetting permissions, changing passwords, etc.) |  | 3d | 2002-02-12 | 2002-02-15 | 245 | 2002-01-01 | 2002-01-04 | 3d | -36.75d | 0d |  |
| 247 | 1.5.1.3.7 | Document steps for backing out if pilot fails |  | 3d | 2002-02-15 | 2002-02-20 | 246 | 2002-01-04 | 2002-01-09 | 3d | -36.75d | 0d |  |
| 248 | 1.5.1.3.8 | Develop the rollout process complete | milestone | 0d | 2002-02-20 | 2002-02-20 | 247 | 2002-01-09 | 2002-01-09 | 0d | -36.75d | 0d |  |
| 249 | 1.5.1.4 | Identify known risks and contingency plans for them |  | 2d | 2002-02-20 | 2002-02-22 | 248 | 2002-01-09 | 2002-01-11 | 2d | -36.75d | 0d |  |
| 250 | 1.5.1.5 | Develop rollback plan |  | 2d | 2002-02-22 | 2002-02-26 | 249 | 2002-01-11 | 2002-01-15 | 2d | -36.75d | 0d |  |
| 251 | 1.5.1.6 | Pilot planning complete | milestone | 0d | 2002-02-26 | 2002-02-26 | 250, 242, 241, 239 | 2002-01-15 | 2002-01-15 | 0d | -36.75d | 0d |  |
| 252 | 1.5.2 | **Deployment** |  | 12d | 2002-02-26 | 2002-03-14 |  | 2002-01-15 | 2002-01-31 | 12d | -36.75d | 0d | as late as possible |
| 253 | 1.5.2.1 | Communicate with pilot users |  | 4h | 2002-03-05 | 2002-03-05 | 251 | 2002-01-15 | 2002-01-16 | 4h | -32.25d | 0d |  |
| 254 | 1.5.2.2 | Conduct user training |  | 1w | 2002-02-26 | 2002-03-05 | 251 | 2002-01-15 | 2002-01-22 | 1w | -36.75d | 0d |  |
| 255 | 1.5.2.3 | Ensure support organization is prepared |  | 4d | 2002-02-27 | 2002-03-05 | 251 | 2002-01-15 | 2002-01-21 | 4d | -35.75d | 0d |  |
| 256 | 1.5.2.4 | Prepare pilot site or sites |  | 2d | 2002-03-05 | 2002-03-07 | 255, 254, 253 | 2002-01-22 | 2002-01-24 | 2d | -36.75d | 0d |  |
| 257 | 1.5.2.5 | Deploy the rollout process |  | 1w | 2002-03-07 | 2002-03-14 | 256 | 2002-01-24 | 2002-01-31 | 1w | -36.75d | 0d |  |
| 258 | 1.5.2.6 | Pilot deployment complete | milestone | 0d | 2002-03-14 | 2002-03-14 | 257 | 2002-01-31 | 2002-01-31 | 0d | -36.75d | 0d |  |

Notes:
- 236: After you have completed your feature design and development and thoroughly tested your feature configurations, you are ready to conduct a pilot project. The deployment teams should set a number of interim delivery milestones, each of which involves solutions development, testing, validating against prespecified performance criteria, and redesign. Tracking deployment issues and efficiently resolving them is vital to reaching your deployment goals while remaining on schedule and within budget. / After your pilot project is running and stable, your sponsor and the deployment team meet to assess the functionality of the new Windows 2000 infrastructure and verify that production rollout and support plans are in place. Primary milestones and deployment documents can include the following: / - Technology validation complete / - Complete and stable functional specification / - POC complete / - Preproduction test complete / - Pilot complete / - Updated risk management plan / - Additional deployment documents you might want to develop include the following: / - Training plan / - Support or help desk plan / - Operations transfer plan

| ID | WBS | Task | Type | Duration | Start | Finish | Predecessors | Baseline start | Baseline finish | Baseline duration | Total slack | Free slack | Constraint |
| --- | --- | --- | --- | --- | --- | --- | --- | --- | --- | --- | --- | --- | --- |
| 259 | 1.5.3 | **Evaluate the Pilot** |  | 8d | 2002-03-14 | 2002-03-26 |  | 2002-01-31 | 2002-02-12 | 8d | -36.75d | 0d | as late as possible |
| 260 | 1.5.3.1 | Conduct desktop test scenarios |  | 1w | 2002-03-14 | 2002-03-21 | 258 | 2002-01-31 | 2002-02-07 | 1w | -36.75d | 0d |  |
| 261 | 1.5.3.2 | Conduct server test scenarios |  | 1w | 2002-03-14 | 2002-03-21 | 258 | 2002-01-31 | 2002-02-07 | 1w | -36.75d | 0d |  |
| 262 | 1.5.3.3 | Conduct third-party application test scenarios |  | 1w | 2002-03-14 | 2002-03-21 | 258 | 2002-01-31 | 2002-02-07 | 1w | -36.75d | 0d |  |
| 263 | 1.5.3.4 | Conduct custom application test scenarios |  | 1w | 2002-03-14 | 2002-03-21 | 258 | 2002-01-31 | 2002-02-07 | 1w | -36.75d | 0d |  |
| 264 | 1.5.3.5 | Conduct coexistence test scenarios |  | 1w | 2002-03-14 | 2002-03-21 | 258 | 2002-01-31 | 2002-02-07 | 1w | -36.75d | 0d |  |
| 265 | 1.5.3.6 | Identify scope changes |  | 3d | 2002-03-21 | 2002-03-26 | 264, 263, 262, 261, 260 | 2002-02-07 | 2002-02-12 | 3d | -36.75d | 0d |  |
| 266 | 1.5.3.7 | Identify cost factors |  | 2d | 2002-03-22 | 2002-03-26 | 264, 263, 262, 261, 260 | 2002-02-07 | 2002-02-11 | 2d | -35.75d | 0d |  |
| 267 | 1.5.3.8 | Identify interoperability issues |  | 3d | 2002-03-21 | 2002-03-26 | 264, 263, 262, 261, 260 | 2002-02-07 | 2002-02-12 | 3d | -36.75d | 0d |  |
| 268 | 1.5.3.9 | Identify unanticipated downtime |  | 2d | 2002-03-22 | 2002-03-26 | 264, 263, 262, 261, 260 | 2002-02-07 | 2002-02-11 | 2d | -35.75d | 0d |  |
| 269 | 1.5.3.10 | Pilot test complete | milestone | 0d | 2002-03-26 | 2002-03-26 | 268, 267, 265, 266 | 2002-02-12 | 2002-02-12 | 0d | -36.75d | 0d |  |
| 270 | 1.5.4 | **Post-Pilot Evaluation** |  | 11d | 2002-03-26 | 2002-04-10 |  | 2002-02-12 | 2002-02-27 | 11d | -36.75d | 0d | as late as possible |
| 271 | 1.5.4.1 | Obtain user feedback |  | 1w | 2002-03-26 | 2002-04-02 | 269 | 2002-02-12 | 2002-02-19 | 1w | -36.75d | 0d |  |
| 272 | 1.5.4.2 | Evaluate lessons learned |  | 2d | 2002-04-02 | 2002-04-04 | 271 | 2002-02-19 | 2002-02-21 | 2d | -36.75d | 0d |  |
| 273 | 1.5.4.3 | Modify items as necessary |  | 2d | 2002-04-04 | 2002-04-08 | 272 | 2002-02-21 | 2002-02-25 | 2d | -36.75d | 0d |  |
| 274 | 1.5.4.4 | Document recommendation for next steps |  | 2d | 2002-04-08 | 2002-04-10 | 273 | 2002-02-25 | 2002-02-27 | 2d | -36.75d | 0d |  |
| 275 | 1.5.4.5 | Post-pilot evaluation complete | milestone | 0d | 2002-04-10 | 2002-04-10 | 274 | 2002-02-27 | 2002-02-27 | 0d | -36.75d | 0d |  |
| 276 | 1.5.5 | Pilot complete | milestone | 0d | 2002-04-10 | 2002-04-10 | 275 | 2002-02-27 | 2002-02-27 | 0d | -36.75d | 0d |  |
| 277 | 1.6 | **Deployment** |  | 25.5d | 2002-04-10 | 2002-05-16 |  | 2002-02-27 | 2002-04-04 | 25.5d | -36.75d | 0d | as late as possible |
| 278 | 1.6.1 | **Communication** |  | 2.5d | 2002-04-10 | 2002-04-15 |  | 2002-02-27 | 2002-03-04 | 2.5d | -36.75d | 0d | as late as possible |
| 279 | 1.6.1.1 | Review communications strategy document |  | 2d | 2002-04-10 | 2002-04-12 | 276 | 2002-02-27 | 2002-03-01 | 2d | -36.75d | 0d |  |
| 280 | 1.6.1.2 | Start communications |  | 4h | 2002-04-12 | 2002-04-12 | 279 | 2002-03-01 | 2002-03-04 | 4h | -36.75d | 0d |  |
| 281 | 1.6.1.3 | Communications complete | milestone | 0d | 2002-04-15 | 2002-04-15 | 280 | 2002-03-04 | 2002-03-04 | 0d | -36.75d | 0d |  |
| 282 | 1.6.2 | **Training** |  | 11d | 2002-04-17 | 2002-05-02 |  | 2002-03-04 | 2002-03-19 | 11d | -34.75d | 0d | as late as possible |
| 283 | 1.6.2.1 | Review education/training strategy document |  | 1d | 2002-04-17 | 2002-04-17 | 281 | 2002-03-04 | 2002-03-05 | 1d | -34.75d | 0d |  |
| 284 | 1.6.2.2 | Conduct administrative training |  | 1w | 2002-04-18 | 2002-04-24 | 283 | 2002-03-05 | 2002-03-12 | 1w | -34.75d | 0d |  |
| 285 | 1.6.2.3 | Conduct user training |  | 1w | 2002-04-25 | 2002-05-01 | 284 | 2002-03-12 | 2002-03-19 | 1w | -34.75d | 0d |  |
| 286 | 1.6.2.4 | Education/training complete | milestone | 0d | 2002-05-02 | 2002-05-02 | 285 | 2002-03-19 | 2002-03-19 | 0d | -34.75d | 0d |  |

Notes:
- 270: At the end of the pilot, evaluate its success and make a recommendation about the next steps to management. Management then decides whether to continue the project beyond the pilot. To help you with the evaluation and recommendation, analyze information from a variety of sources.
- 277: At this point, you have tested all of your designs in the lab and conducted a pilot program to refine your plan and further test your designs. Now you are ready to incrementally deploy Windows 2000 throughout your enterprise. / During the production rollout phase, testing and support activities are still important as iterative cycles of deployment, testing, validation, and support become the primary focus. The new Windows 2000 Server and Windows 2000 Professional infrastructure is formally turned over to the operations and support groups at the deployment complete milestone. A project review should be conducted.

| ID | WBS | Task | Type | Duration | Start | Finish | Predecessors | Baseline start | Baseline finish | Baseline duration | Total slack | Free slack | Constraint |
| --- | --- | --- | --- | --- | --- | --- | --- | --- | --- | --- | --- | --- | --- |
| 287 | 1.6.3 | **Domain Deployment** |  | 13d | 2002-04-15 | 2002-05-02 |  | 2002-03-04 | 2002-03-21 | 13d | -36.75d | 0d | as late as possible |
| 288 | 1.6.3.1 | Review domain migration strategy/standards document |  | 2d | 2002-04-15 | 2002-04-16 | 281 | 2002-03-04 | 2002-03-06 | 2d | -36.75d | 0d |  |
| 289 | 1.6.3.2 | Restructure existing Windows NT 4.0 domains |  | 1w | 2002-04-17 | 2002-04-23 | 288 | 2002-03-06 | 2002-03-13 | 1w | -36.75d | 0d |  |
| 290 | 1.6.3.3 | Upgrade PDC to Windows 2000 |  | 4h | 2002-04-24 | 2002-04-24 | 289 | 2002-03-13 | 2002-03-13 | 4h | -36.75d | 0d |  |
| 291 | 1.6.3.4 | Upgrade BDCs to Windows 2000 |  | 1d | 2002-04-24 | 2002-04-25 | 290 | 2002-03-13 | 2002-03-14 | 1d | -36.75d | 0d |  |
| 292 | 1.6.3.5 | Upgrade resource domains |  | 1d | 2002-04-25 | 2002-04-26 | 291 | 2002-03-14 | 2002-03-15 | 1d | -36.75d | 0d |  |
| 293 | 1.6.3.6 | **Member Server Migration** |  | 3d | 2002-04-26 | 2002-05-01 |  | 2002-03-15 | 2002-03-20 | 3d | -36.75d | 0d | as late as possible |
| 294 | 1.6.3.6.1 | Review member server migration strategy/standards document |  | 1d | 2002-04-26 | 2002-04-29 | 292 | 2002-03-15 | 2002-03-18 | 1d | -36.75d | 0d |  |
| 295 | 1.6.3.6.2 | Backup files on servers to be upgraded |  | 4h | 2002-04-29 | 2002-04-29 | 294 | 2002-03-18 | 2002-03-19 | 4h | -36.75d | 0d |  |
| 296 | 1.6.3.6.3 | Upgrade member server |  | 4h | 2002-04-30 | 2002-04-30 | 295 | 2002-03-19 | 2002-03-19 | 4h | -36.75d | 0d |  |
| 297 | 1.6.3.6.4 | Test member server on network |  | 1d | 2002-04-30 | 2002-05-01 | 296 | 2002-03-19 | 2002-03-20 | 1d | -36.75d | 0d |  |
| 298 | 1.6.3.6.5 | Member server migration complete | milestone | 0d | 2002-05-01 | 2002-05-01 | 297 | 2002-03-20 | 2002-03-20 | 0d | -36.75d | 0d |  |
| 299 | 1.6.3.7 | Establish trusts |  | 4h | 2002-05-01 | 2002-05-01 | 298 | 2002-03-20 | 2002-03-21 | 4h | -36.75d | 0d |  |
| 300 | 1.6.3.8 | Domain migration complete | milestone | 0d | 2002-05-02 | 2002-05-02 | 299, 286 | 2002-03-21 | 2002-03-21 | 0d | -36.75d | 0d |  |
| 301 | 1.6.4 | **Security Infrastructure** |  | 4d | 2002-05-10 | 2002-05-16 |  | 2002-03-21 | 2002-03-27 | 4d | -30.75d | 0d | as late as possible |
| 302 | 1.6.4.1 | Review security strategy/standards document |  | 4h | 2002-05-10 | 2002-05-10 | 300 | 2002-03-21 | 2002-03-21 | 4h | -30.75d | 0d |  |
| 303 | 1.6.4.2 | Create secure boundaries |  | 1d | 2002-05-10 | 2002-05-13 | 302 | 2002-03-21 | 2002-03-22 | 1d | -30.75d | 0d |  |
| 304 | 1.6.4.3 | Deploy strategies for everyone |  | 4h | 2002-05-13 | 2002-05-13 | 303 | 2002-03-22 | 2002-03-25 | 4h | -30.75d | 0d |  |
| 305 | 1.6.4.4 | Deploy strategies for company staff |  | 4h | 2002-05-14 | 2002-05-14 | 304 | 2002-03-25 | 2002-03-25 | 4h | -30.75d | 0d |  |
| 306 | 1.6.4.5 | Deploy strategies for users of company applications |  | 4h | 2002-05-14 | 2002-05-14 | 305 | 2002-03-25 | 2002-03-26 | 4h | -30.75d | 0d |  |
| 307 | 1.6.4.6 | Deploy strategies for partners |  | 1d | 2002-05-15 | 2002-05-15 | 306 | 2002-03-26 | 2002-03-27 | 1d | -30.75d | 0d |  |
| 308 | 1.6.4.7 | Security complete | milestone | 0d | 2002-05-16 | 2002-05-16 | 307 | 2002-03-27 | 2002-03-27 | 0d | -30.75d | 0d |  |
| 309 | 1.6.5 | **Public Key Infrastructure** |  | 10d | 2002-05-02 | 2002-05-16 |  | 2002-03-21 | 2002-04-04 | 10d | -36.75d | 0d | as late as possible |
| 310 | 1.6.5.1 | Review public key strategy/standards document |  | 1d | 2002-05-02 | 2002-05-02 | 300 | 2002-03-21 | 2002-03-22 | 1d | -36.75d | 0d |  |
| 311 | 1.6.5.2 | Providing training and support for production users |  | 1w | 2002-05-03 | 2002-05-09 | 310 | 2002-03-22 | 2002-03-29 | 1w | -36.75d | 0d |  |
| 312 | 1.6.5.3 | Install CAs |  | 4h | 2002-05-10 | 2002-05-10 | 311 | 2002-03-29 | 2002-03-29 | 4h | -36.75d | 0d |  |
| 313 | 1.6.5.4 | Install/configure support systems or applications |  | 4h | 2002-05-10 | 2002-05-10 | 312 | 2002-03-29 | 2002-04-01 | 4h | -36.75d | 0d |  |
| 314 | 1.6.5.5 | Configure the certificates to be used |  | 4h | 2002-05-13 | 2002-05-13 | 313 | 2002-04-01 | 2002-04-01 | 4h | -36.75d | 0d |  |
| 315 | 1.6.5.6 | Configure certificate revocation lists publication |  | 4h | 2002-05-13 | 2002-05-13 | 314 | 2002-04-01 | 2002-04-02 | 4h | -36.75d | 0d |  |
| 316 | 1.6.5.7 | Configure public key Group Policy |  | 4h | 2002-05-14 | 2002-05-14 | 315 | 2002-04-02 | 2002-04-02 | 4h | -36.75d | 0d |  |
| 317 | 1.6.5.8 | Configure certificate renewal and enrollment |  | 4h | 2002-05-14 | 2002-05-14 | 316 | 2002-04-02 | 2002-04-03 | 4h | -36.75d | 0d |  |
| 318 | 1.6.5.9 | Issue certificates to users, computers, and services |  | 1d | 2002-05-15 | 2002-05-15 | 317 | 2002-04-03 | 2002-04-04 | 1d | -36.75d | 0d |  |
| 319 | 1.6.5.10 | Public key infrastructure complete | milestone | 0d | 2002-05-16 | 2002-05-16 | 318 | 2002-04-04 | 2002-04-04 | 0d | -36.75d | 0d |  |

| ID | WBS | Task | Type | Duration | Start | Finish | Predecessors | Baseline start | Baseline finish | Baseline duration | Total slack | Free slack | Constraint |
| --- | --- | --- | --- | --- | --- | --- | --- | --- | --- | --- | --- | --- | --- |
| 320 | 1.6.6 | **High-Availability Applications/Services (Clustering)** |  | 6.5d | 2002-05-07 | 2002-05-16 |  | 2002-03-21 | 2002-03-29 | 6.5d | -33.25d | 0d | as late as possible |
| 321 | 1.6.6.1 | Review high availability applications/services (clustering) document |  | 1d | 2002-05-07 | 2002-05-08 | 300 | 2002-03-21 | 2002-03-22 | 1d | -33.25d | 0d |  |
| 322 | 1.6.6.2 | Optimize Windows 2000 cluster service |  | 1d | 2002-05-08 | 2002-05-09 | 321 | 2002-03-22 | 2002-03-25 | 1d | -33.25d | 0d |  |
| 323 | 1.6.6.3 | Choose tools to help you automate the deployment of Windows 2000 cluster service |  | 4h | 2002-05-09 | 2002-05-09 | 322 | 2002-03-25 | 2002-03-25 | 4h | -33.25d | 0d |  |
| 324 | 1.6.6.4 | Optimize your clusters |  | 1d | 2002-05-10 | 2002-05-10 | 323 | 2002-03-25 | 2002-03-26 | 1d | -33.25d | 0d |  |
| 325 | 1.6.6.5 | Plan for fault-tolerant disks |  | 1d | 2002-05-13 | 2002-05-13 | 324 | 2002-03-26 | 2002-03-27 | 1d | -33.25d | 0d |  |
| 326 | 1.6.6.6 | Test server capacity |  | 1d | 2002-05-14 | 2002-05-14 | 325 | 2002-03-27 | 2002-03-28 | 1d | -33.25d | 0d |  |
| 327 | 1.6.6.7 | Plan a backup and recovery strategy |  | 1d | 2002-05-15 | 2002-05-15 | 326 | 2002-03-28 | 2002-03-29 | 1d | -33.25d | 0d |  |
| 328 | 1.6.6.8 | High-availability applications/services (clustering) complete | milestone | 0d | 2002-05-16 | 2002-05-16 | 327 | 2002-03-29 | 2002-03-29 | 0d | -33.25d | 0d |  |
| 329 | 1.6.7 | **Storage Management Strategies** |  | 8.5d | 2002-05-03 | 2002-05-15 |  | 2002-03-21 | 2002-04-02 | 8.5d | -35.25d | 0d | as late as possible |
| 330 | 1.6.7.1 | Review storage management strategy/standards document |  | 1d | 2002-05-03 | 2002-05-06 | 300 | 2002-03-21 | 2002-03-22 | 1d | -35.25d | 0d |  |
| 331 | 1.6.7.2 | Review business requirements for storage |  | 4h | 2002-05-06 | 2002-05-06 | 330 | 2002-03-22 | 2002-03-22 | 4h | -35.25d | 0d |  |
| 332 | 1.6.7.3 | Design storage management solution |  | 2d | 2002-05-07 | 2002-05-08 | 331 | 2002-03-22 | 2002-03-26 | 2d | -35.25d | 0d |  |
| 333 | 1.6.7.4 | Design storage utilities (backup, restore, defragmentation) |  | 1d | 2002-05-09 | 2002-05-09 | 332 | 2002-03-26 | 2002-03-27 | 1d | -35.25d | 0d |  |
| 334 | 1.6.7.5 | Design disaster recovery plan |  | 2d | 2002-05-10 | 2002-05-13 | 333 | 2002-03-27 | 2002-03-29 | 2d | -35.25d | 0d |  |
| 335 | 1.6.7.6 | Document storage management strategy/standards |  | 1d | 2002-05-14 | 2002-05-14 | 334 | 2002-03-29 | 2002-04-01 | 1d | -35.25d | 0d |  |
| 336 | 1.6.7.7 | Storage management strategies complete | milestone | 0d | 2002-05-15 | 2002-05-15 | 335 | 2002-04-01 | 2002-04-01 | 0d | -35.25d | 0d |  |
| 337 | 1.6.7.8 | Switch to native mode |  | 1d | 2002-05-15 | 2002-05-15 | 336 | 2002-04-01 | 2002-04-02 | 1d | -35.25d | 0d |  |
| 338 | 1.6.8 | Deployment complete | milestone | 0d | 2002-05-16 | 2002-05-16 | 337, 328, 319, 308 | 2002-04-04 | 2002-04-04 | 0d | -36.75d | 0d |  |
| 339 | 1.7 | **Post-Implementation Review** |  | 12d | 2002-05-16 | 2002-05-31 |  | 2002-04-04 | 2002-04-22 | 12d | -36.75d | 0d | as late as possible |
| 340 | 1.7.1 | Obtain user feedback |  | 1w | 2002-05-16 | 2002-05-22 | 338 | 2002-04-04 | 2002-04-11 | 1w | -36.75d | 0d |  |
| 341 | 1.7.2 | Evaluate lessons learned |  | 4d | 2002-05-23 | 2002-05-28 | 340 | 2002-04-11 | 2002-04-17 | 4d | -36.75d | 0d |  |
| 342 | 1.7.3 | Modify items as necessary |  | 2d | 2002-05-29 | 2002-05-30 | 341 | 2002-04-17 | 2002-04-19 | 2d | -36.75d | 0d |  |
| 343 | 1.7.4 | Establish ongoing infrastructure planning team |  | 1d | 2002-05-31 | 2002-05-31 | 342 | 2002-04-19 | 2002-04-22 | 1d | -36.75d | 0d |  |
| 344 | 1.7.5 | Post-implementation review complete | milestone | 0d | 2002-05-31 | 2002-05-31 | 343 | 2002-04-22 | 2002-04-22 | 0d | -36.75d | 0d |  |

Notes:
- 339: This is the final phase for the project. During this phase, you will review the project and document the lessons learned to provide a foundation for future deployment projects or post-implementation directives.
- 343: The Windows 2000 planning team, composed of various deployment resources, should be established to recommend future application development, maintenance, service releases, and future versions.
